# RUP Project Plan

Schedule from MS Project, 2009-06-01 to 2009-12-21, A marks actual dates.
Sapient for NCI/caCORE

## Calendars

- Standard: Mon-Fri 08:00-12:00, 13:00-17:00; Sat-Sun off. Exceptions (off unless hours are given): 2009-07-03, 2009-07-20 to 2009-07-22, 2009-09-07, 2009-11-26 to 2009-11-27.

## Resources

| Resource |
| --- |
| Team |
| QA |
| Systems |
| Tom |
| Traci |
| Johnita |
| Jason |
| Satya |
| Scott |
| Shalini |
| Kevin |
| Craig |
| Tracy |
| Steve |
| Mayo/NCI |
| Eddie |
| Systems Team |
| C |
| Scott/Craig |
| Scott/Kevin |
| NCI |
| Mike |
| Web App |
| Marilyn |
| Tech Writer |
| Criag |
| VKC |
| Rick |
| Craig/Kevin |
| Harold |
| Raghu |
| Stev |
| Security |
| Frank |
| Sridhar |
| Tracy? |
| Denis |
| Marylyn |

## Schedule

| ID | WBS | Task | Duration | Start | Finish | Predecessors | Complete | Constraint | Resources | Work | Actual work | Text12 |
| --- | --- | --- | --- | --- | --- | --- | --- | --- | --- | --- | --- | --- |
| 1 | 1 | **Inception** | 20d | 2009-06-01 A | 2009-06-26 A |  | 100% |  |  | 160h | 160h |  |
| 2 | 1.1 | **Requirements** | 20d | 2009-06-01 A | 2009-06-26 A |  | 100% |  |  | 160h | 160h |  |
| 3 | 1.1.1 | Gather requirements | 2w | 2009-06-01 A | 2009-06-12 A |  | 100% | start no earlier than 2009-06-01 | Team | 80h | 80h |  |
| 4 | 1.1.2 | Complete requirements | 2w | 2009-06-15 A | 2009-06-26 A | 3 | 100% |  | Team | 80h | 80h |  |
| 5 | 2 | **Elaboration** | 21d | 2009-06-15 A | 2009-07-14 A |  | 100% |  |  | 160h | 160h |  |
| 6 | 2.1 | **Scope Definition** | 11d | 2009-06-15 A | 2009-06-29 A |  | 100% |  |  | 80h | 80h |  |
| 7 | 2.1.1 | Draft Scope Wiki | 2d | 2009-06-15 A | 2009-06-16 A |  | 100% | start no earlier than 2009-06-15 | Traci | 16h | 16h |  |
| 8 | 2.1.2 | Review Scope | 4d | 2009-06-17 A | 2009-06-22 A | 7 | 100% |  | Raghu | 32h | 32h |  |
| 9 | 2.1.3 | Finalize Scope | 4d | 2009-06-23 A | 2009-06-26 A | 8 | 100% |  | Traci | 32h | 32h |  |
| 10 | 2.1.4 | Obtain signoff from Frank of 5.0 Scope | 1d | 2009-06-29 A | 2009-06-29 A | 9 | 100% | start no earlier than 2008-11-12 |  |  |  |  |
| 11 | 2.2 | **Project Management** | 10d | 2009-06-30 A | 2009-07-14 A |  | 100% |  |  | 80h | 80h |  |
| 12 | 2.2.1 | Draft task plan | 2w | 2009-06-30 A | 2009-07-14 A |  | 100% |  | Traci | 80h | 80h |  |
| 13 | 3 | **Construction** | 101.5d | 2009-06-18 A | 2009-11-13 A |  | 100% |  |  | 3148h | 3148h |  |
| 14 | 3.1 | **Gforge Items (code & junit)** | 38d | 2009-06-30 A | 2009-08-26 A |  | 100% |  |  | 360h | 360h |  |
| 15 | 3.1.1 | The NCI_Thesaurus association Has_Salt_Form and Has_Free_Acid_Or_Base needs reverse name | 1d | 2009-07-15 A | 2009-07-15 A |  | 100% | start no earlier than 2009-07-15 | Craig | 8h | 8h | 15075 |
| 16 | 3.1.2 | Unescaping XML character data in complex properties | 6w | 2009-06-30 A | 2009-08-14 A |  | 100% |  | Scott | 240h | 240h | 20875 |
| 17 | 3.1.3 | User question about Metathesaurus Term-group | 1d | 2009-06-30 A | 2009-06-30 A |  | 100% |  | Kevin | 8h | 8h | 20896 |
| 18 | 3.1.4 | SNOMED Full Name instead of Full form. | 1d | 2009-06-30 A | 2009-06-30 A |  | 100% |  | Kevin | 8h | 8h | 21267 |
| 19 | 3.1.5 | Lucene Max Clause Count exceeded on broad NCI MetaThesaurus RegExp Restrictions | 2d | 2009-08-03 A | 2009-08-04 A | 46 | 100% | start no earlier than 2009-08-03 | Craig | 16h | 16h | 21336 |
| 20 | 3.1.6 | ResourceManager cache not Thread-safe | 1d | 2009-06-30 A | 2009-06-30 A |  | 100% |  | Kevin | 8h | 8h | 21567 |
| 21 | 3.1.7 | CodedNodeGraph resolveAsList distributed method encountered Jaa heap space error | 3d | 2009-08-03 A | 2009-08-05 A | 19SS | 100% |  | Craig | 24h | 24h | 21739 |
| 22 | 3.1.8 | Heap space error on Double Metaphone MetaThesaurus query | 2d | 2009-08-03 A | 2009-08-04 A | 19SS | 100% |  | Craig | 16h | 16h | 21740 |
| 23 | 3.1.9 | Connection Leak on SQLImplementedMethods 'mapToCodingSchemeName' | 1d | 2009-06-30 A | 2009-06-30 A |  | 100% |  | Kevin | 8h | 8h | 21923 |
| 24 | 3.1.10 | OWL loader processing associations incorrectly | 1d | 2009-06-30 A | 2009-06-30 A |  | 100% |  | Kevin | 8h | 8h | 21935 |
| 25 | 3.1.11 | Make sample programs (in the examples folder) runnable under both local and distributed modes. | 1d | 2009-08-05 A | 2009-08-06 A | 21 | 100% |  | Craig | 8h | 8h | 21880 |
| 26 | 3.1.12 | OWL load of OBI fails | 1d | 2009-08-26 A | 2009-08-26 A |  | 100% | start no earlier than 2009-08-26 | Kevin | 8h | 8h | 22866 |

Notes:
- 19: Dependent on Lucene changes for search/performance. Will need to test to detemine if this is then resolved.

| ID | WBS | Task | Type | Duration | Start | Finish | Predecessors | Complete | Constraint | Resources | Work | Actual work | Text12 |
| --- | --- | --- | --- | --- | --- | --- | --- | --- | --- | --- | --- | --- | --- |
| 27 | 3.2 | **RRF Data issues** |  | 38.5d | 2009-06-30 A | 2009-08-27 A |  | 100% |  |  | 276h | 276h |  |
| 28 | 3.2.1 | MRSAB conifgured to load for NCI Meta data |  | 1w | 2009-06-30 A | 2009-07-07 A |  | 100% |  | Scott | 40h | 40h | 21717 |
| 29 | 3.2.2 | Add data from MRSAT file to NCI Meta data |  | 1w | 2009-07-06 A | 2009-07-10 A |  | 100% | start no earlier than 2009-07-06 | Scott | 40h | 40h | 21716 |
| 30 | 3.2.3 | Load MRRANK data for NCI Meta |  | 1w | 2009-07-17 A | 2009-07-28 A | 29 | 100% | finish no earlier than 2009-07-28 | Scott | 40h | 40h | 21719 |
| 31 | 3.2.4 | MRREL data for NCi Meta - needs more data loaded |  | 1w | 2009-07-29 A | 2009-08-04 A | 30 | 100% |  | Scott | 40h | 40h | 21718 |
| 32 | 3.2.5 | Load all MRMAP data | milestone | 0w | 2009-08-04 A | 2009-08-04 A | 31 | 100% |  | Scott |  |  | 21720 |
| 33 | 3.2.6 | Add some additional data from MRHIER |  | 0.5w | 2009-08-05 A | 2009-08-07 A | 32 | 100% |  | Scott | 20h | 20h | 21721 |
| 34 | 3.2.7 | Make sure MRDOC data for NCI Meta is loaded |  | 3d | 2009-08-07 A | 2009-08-12 A | 33 | 100% |  | Scott | 24h | 24h | 21722 |
| 35 | 3.2.8 | Add more data from MRDEF file for NCI Meta |  | 3d | 2009-08-19 A | 2009-08-24 A | 34 | 100% |  | Scott | 24h | 24h | 21723 |
| 36 | 3.2.9 | Add data from MRCONSO file to NCI Meta data |  | 3d | 2009-08-24 A | 2009-08-27 A | 35 | 100% |  | Scott | 24h | 24h | 21724 |
| 37 | 3.2.10 | Displaying multiple concept status. (deferred) | milestone | 0d | 2009-08-27 A | 2009-08-27 A | 36 | 100% |  | Kevin |  |  | 21278 |
| 38 | 3.2.11 | Update the Design document with RRF design plans |  | 3d | 2009-07-30 A | 2009-08-03 A |  | 100% | finish no earlier than 2009-08-03 | Scott | 24h | 24h |  |
| 39 | 3.3 | **Search & Sort Enhancements** |  | 32.5d | 2009-06-18 A | 2009-08-07 A |  | 100% |  |  | 376h | 376h |  |
| 40 | 3.3.1 | Improve error messages (e.g., CNS.resolve, CNS.resolveToList, CNG.resolveToList) |  | 3w | 2009-06-30 A | 2009-07-24 A |  | 100% |  | Mike | 120h | 120h | 21879 |
| 41 | 3.3.2 | Add an algorithm for supporting case-insensitive substring search. |  | 2w | 2009-07-27 A | 2009-08-07 A | 40 | 100% |  | Mike; Craig [20%] | 96h | 96h | 21849 |
| 42 | 3.3.3 | Add a search algorithm for supporting case-insensitive substring search with an additional spelling-error tolerant feature. |  | 1w | 2009-06-18 A | 2009-07-31 A |  | 100% | finish no earlier than 2009-07-31 | Kevin | 40h | 40h | 21850 |
| 43 | 3.3.4 | Add a sort option for ranking matched concepts by similarity score. |  | 1w | 2009-08-03 A | 2009-08-07 A | 47 | 100% |  | Kevin | 40h | 40h | 21851 |
| 44 | 3.3.5 | Update Design document with Search/sort enhancements |  | 5d | 2009-07-29 A | 2009-08-04 A |  | 100% | start no earlier than 2009-07-29 | Mike; Kevin | 80h | 80h |  |
| 45 | 3.4 | **Performance Enhancements for Metathesaurus Browser** |  | 35d | 2009-06-30 A | 2009-08-21 A |  | 100% |  |  | 304h | 304h |  |
| 46 | 3.4.1 | Optimize Lucene code to improve search performance |  | 2w | 2009-06-30 A | 2009-07-14 A |  | 100% |  | Kevin | 80h | 80h | 21980 |
| 47 | 3.4.2 | Implement a server side sort to improve performance |  | 2w | 2009-07-15 A | 2009-07-31 A | 46 | 100% |  | Kevin | 80h | 80h | 21982 |
| 48 | 3.4.3 | General SQL optimization |  | 2w | 2009-08-03 A | 2009-08-14 A | 47 | 100% |  | Kevin | 80h | 80h | 22006 |
| 49 | 3.4.4 | Improve ResolvedConceptReferencesIterator performance by reducing client-server network traffic in distributed mode. |  | 1w | 2009-08-17 A | 2009-08-21 A | 48 | 100% |  | Kevin | 40h | 40h | 21881 |
| 50 | 3.4.5 | Update Design document with performance enhancement items |  | 3d | 2009-08-03 A | 2009-08-05 A |  | 100% | start no earlier than 2009-08-03 | Kevin | 24h | 24h |  |

Notes:
- 32: Deferred for 5.1

| ID | WBS | Task | Type | Duration | Start | Finish | Predecessors | Complete | Constraint | Resources | Work | Actual work | Text12 |
| --- | --- | --- | --- | --- | --- | --- | --- | --- | --- | --- | --- | --- | --- |
| 51 | 3.5 | **Value Set Support** |  | 44d | 2009-06-30 A | 2009-09-03 A |  | 100% |  |  | 488h | 488h |  |
| 52 | 3.5.1 | Analysis & determine recommendation |  | 3w | 2009-06-30 A | 2009-07-24 A |  | 100% |  | Sridhar; Harold | 240h | 240h |  |
| 53 | 3.5.2 | Document recommendation in Design Document |  | 2w | 2009-07-27 A | 2009-08-07 A | 52 | 100% | finish no earlier than 2009-08-07 | Sridhar | 80h | 80h |  |
| 54 | 3.5.3 | Implementation of value set support |  | 3.8w | 2009-08-10 A | 2009-09-03 A | 53 | 100% | finish no earlier than 2009-09-03 | Sridhar | 152h | 152h |  |
| 55 | 3.5.4 | BDA script for value domain |  | 2d | 2009-08-27 A | 2009-08-28 A |  | 100% | start no earlier than 2009-08-27 | Scott | 16h | 16h |  |
| 56 | 3.6 | **Improved Loading Framework** |  | 42d | 2009-07-06 A | 2009-09-04 A |  | 100% |  |  | 304h | 304h |  |
| 57 | 3.6.1 | Review current framework |  | 1d | 2009-07-06 A | 2009-07-06 A |  | 100% | start no earlier than 2009-07-06 | Kevin; Mike | 16h | 16h |  |
| 58 | 3.6.2 | Code review |  | 3d | 2009-07-07 A | 2009-07-09 A | 57 | 100% |  | Mike | 24h | 24h |  |
| 59 | 3.6.3 | Design and document loader framework |  | 20h | 2009-07-27 A | 2009-07-29 A | 58 | 100% | start no earlier than 2009-07-27 | Kevin; Mike | 40h | 40h |  |
| 60 | 3.6.4 | Design & document custom loader feasibility |  | 3d | 2009-07-29 A | 2009-08-03 A | 59 | 100% | start no earlier than 2009-07-23 | Mike | 24h | 24h |  |
| 61 | 3.6.5 | Implementation of loader framework |  | 4w | 2009-08-10 A | 2009-09-04 A |  | 100% | start no earlier than 2009-08-10 | Kevin | 160h | 160h |  |
| 62 | 3.6.6 | Removing Maven and substituting with Ivy |  | 1w | 2009-08-31 A | 2009-09-04 A |  | 100% | start no earlier than 2009-08-31 | Kevin | 40h | 40h |  |
| 63 | 3.7 | **BDA** |  | 34.5d | 2009-07-06 A | 2009-08-26 A |  | 100% |  |  | 104h | 104h |  |
| 64 | 3.7.1 | Investigate to Ivy |  | 2w | 2009-07-06 A | 2009-07-17 A |  | 100% | start no earlier than 2009-07-06 | Scott | 80h | 80h |  |
| 65 | 3.7.2 | Develop BDA script for Dev |  | 0.5d | 2009-08-24 A | 2009-08-24 A |  | 100% | start no earlier than 2009-08-24 | Scott | 4h | 4h |  |
| 66 | 3.7.3 | Develop BDA script for QA |  | 0.5d | 2009-08-24 A | 2009-08-24 A | 65 | 100% |  | Scott | 4h | 4h |  |
| 67 | 3.7.4 | Develop BDA script for Stage |  | 0.5d | 2009-08-25 A | 2009-08-25 A | 66 | 100% |  | Scott | 4h | 4h |  |
| 68 | 3.7.5 | Develop BDA script for Prod |  | 0.5d | 2009-08-25 A | 2009-08-25 A | 67 | 100% |  | Scott | 4h | 4h |  |
| 69 | 3.7.6 | Request AntHIll pro tracks for all tiers |  | 1d | 2009-08-25 A | 2009-08-26 A |  | 100% | start no earlier than 2009-08-25 | Scott | 8h | 8h |  |
| 70 | 3.8 | **DesignDocumentation** |  | 5d | 2009-08-05 A | 2009-08-11 A |  | 100% |  |  | 160h | 160h |  |
| 71 | 3.8.1 | Finalize design document and Implementation Plan |  | 1w | 2009-08-05 A | 2009-08-11 A |  | 100% | start no earlier than 2009-08-05 | Craig; Scott | 80h | 80h | 21990 |
| 72 | 3.8.2 | Finalize test plan |  | 1w | 2009-08-05 A | 2009-08-11 A |  | 100% |  | Scott | 40h | 40h | 21988 |
| 73 | 3.8.3 | Custom loading feasibility report |  | 1w | 2009-08-05 A | 2009-08-11 A |  | 100% |  | Mike | 40h | 40h | 21979 |
| 74 | 3.9 | **Boot Camp** |  | 58d | 2009-08-25 A | 2009-11-13 A |  | 100% |  |  | 776h | 776h |  |
| 75 | 3.9.1 | Ia content draft | milestone | 0d | 2009-08-27 A | 2009-08-27 A |  | 100% | start no earlier than 2009-08-27 | NCI |  |  |  |
| 76 | 3.9.2 | Complete setup instructions for hands-on training |  | 1w | 2009-08-27 A | 2009-09-02 A | 75 | 100% |  | Craig; Traci | 80h | 80h |  |
| 77 | 3.9.3 | Complete training ppt templates |  | 26d | 2009-08-25 A | 2009-09-30 A |  | 100% | start no earlier than 2009-08-25 | Craig; Traci; NCI | 624h | 624h |  |
| 78 | 3.9.4 | Finalize content | milestone | 0d | 2009-10-30 A | 2009-10-30 A |  | 100% | start no earlier than 2009-10-30 | Team |  |  |  |
| 79 | 3.9.5 | Boot Camp training dates |  | 3d | 2009-11-11 A | 2009-11-13 A |  | 100% | start no earlier than 2009-11-11 | Craig; Scott; Kevin | 72h | 72h |  |

| ID | WBS | Task | Type | Duration | Start | Finish | Predecessors | Complete | Constraint | Deadline | Resources | Work | Actual work | Text12 |
| --- | --- | --- | --- | --- | --- | --- | --- | --- | --- | --- | --- | --- | --- | --- |
| 80 | 4 | **Testing** |  | 83.88d | 2009-08-07 A | 2009-12-07 A |  | 100% |  |  |  | 853h | 853h |  |
| 81 | 4.1 | Request Jboss containers (2) |  | 1h | 2009-08-07 A | 2009-08-07 A |  | 100% | start no earlier than 2009-08-07 |  | Craig | 1h | 1h |  |
| 82 | 4.2 | Receive Jboss containers | milestone | 0d | 2009-09-11 A | 2009-09-11 A | 81FS+1w | 100% | start no earlier than 2009-09-11 |  | Systems |  |  |  |
| 83 | 4.3 | Receive URLS | milestone | 0w | 2009-09-11 A | 2009-09-11 A |  | 100% | start no earlier than 2009-09-11 |  | Systems |  |  |  |
| 84 | 4.4 | Create 5.1 build |  | 1d | 2009-09-08 A | 2009-09-08 A | 56, 51 | 100% |  | 2009-09-08 |  |  |  |  |
| 85 | 4.5 | Mayo Dev testing (LexBig, distributed, data services, grid junits) |  | 9d | 2009-09-09 A | 2009-09-21 A | 84 | 100% |  |  | Kevin | 72h | 72h |  |
| 86 | 4.6 | **Bug fixes** |  | 4d | 2009-09-14 A | 2009-09-17 A | 85SS | 100% |  |  |  | 120h | 120h |  |
| 87 | 4.6.1 | 23340 - Association name |  | 4d | 2009-09-14 A | 2009-09-17 A |  | 100% |  |  | Kevin | 32h | 32h |  |
| 88 | 4.6.2 | OWL issues |  | 3d | 2009-09-14 A | 2009-09-16 A |  | 100% |  |  | Scott | 24h | 24h |  |
| 89 | 4.6.3 | 23350 - History service |  | 2d | 2009-09-14 A | 2009-09-15 A |  | 100% |  |  | Kevin; Scott | 32h | 32h |  |
| 90 | 4.6.4 | 23286 - permission |  | 2d | 2009-09-14 A | 2009-09-15 A |  | 100% | start no earlier than 2009-09-14 |  | Kevin; Scott | 32h | 32h |  |
| 91 | 4.7 | Request EVS API URLs from Systems Team for tier level services |  | 1h | 2009-08-07 A | 2009-08-07 A | 81 | 100% |  |  | Craig | 1h | 1h |  |
| 92 | 4.8 | Request Grid URLs from Systems Team for tier level services |  | 1h | 2009-08-19 A | 2009-08-19 A | 82 | 100% |  |  | Craig | 1h | 1h |  |
| 93 | 4.9 | Meeting w/QA Mgr & Systems for deployment (ARC) |  | 2h | 2009-08-07 A | 2009-08-07 A | 81SS | 100% |  |  | Mayo/NCI | 2h | 2h |  |
| 94 | 4.10 | Update home.jsp |  | 1h | 2009-09-22 A | 2009-09-22 A | 85 | 100% |  |  | Craig | 1h | 1h |  |
| 95 | 4.11 | **Dev** |  | 18d | 2009-09-22 A | 2009-10-15 A | 85 | 100% |  |  |  | 224h | 224h |  |
| 96 | 4.11.1 | Promote to NCI Dev |  | 1d | 2009-09-22 A | 2009-09-22 A | 83 | 100% | start no earlier than 2009-02-23 |  | Scott; Tracy | 16h | 16h | 21993 |
| 97 | 4.11.2 | Execute Test cases (Distributed, Grid, Data junits) |  | 2d | 2009-09-23 A | 2009-09-24 A | 96 | 100% |  |  | Kevin | 16h | 16h |  |
| 98 | 4.11.3 | Load Content |  | 2w | 2009-09-29 A | 2009-10-12 A |  | 100% | start no earlier than 2009-02-17 |  | Tracy | 80h | 80h |  |
| 99 | 4.11.4 | Bug fixes |  | 2w | 2009-09-23 A | 2009-10-06 A |  | 100% | start no earlier than 2009-09-23 |  | Team | 80h | 80h |  |
| 100 | 4.11.5 | 2nd deployment to Dev |  | 0.5d | 2009-10-08 A | 2009-10-08 A | 99 | 100% | start no earlier than 2009-10-08 |  | Scott; Kevin | 8h | 8h |  |
| 101 | 4.11.6 | Re-execute test cases (Distributed, Grid, Data junits) |  | 2d | 2009-10-08 A | 2009-10-12 A | 100 | 100% |  |  | Kevin | 16h | 16h |  |
| 102 | 4.11.7 | Promote content to QA |  | 1d | 2009-10-15 A | 2009-10-15 A |  | 100% | start no earlier than 2009-10-15 |  | Systems | 8h | 8h |  |
| 103 | 4.12 | **QA** |  | 28.62d | 2009-10-06 A | 2009-11-13 A |  | 100% |  |  |  | 266h | 266h |  |
| 104 | 4.12.1 | Receive Jboss containers & URLS from Systems Team | milestone | 0d | 2009-10-06 A | 2009-10-06 A |  | 100% | start no earlier than 2009-10-06 |  |  |  |  |  |
| 105 | 4.12.2 | Create QA tag in SVN |  | 1h | 2009-10-12 A | 2009-10-12 A | 101 | 100% | start no earlier than 2009-10-12 |  | Scott | 1h | 1h |  |
| 106 | 4.12.3 | draft deployment request for Steve |  | 2h | 2009-10-12 A | 2009-10-12 A | 101 | 100% | start no earlier than 2009-10-09 |  | Scott | 2h | 2h |  |
| 107 | 4.12.4 | Promote to QA |  | 5d | 2009-10-16 A | 2009-10-22 A |  | 100% | finish no earlier than 2009-10-22 |  | Steve | 40h | 40h | 21994 |
| 108 | 4.12.5 | Execute Test cases |  | 1w | 2009-10-23 A | 2009-10-29 A | 107 | 100% |  |  | Steve | 40h | 40h |  |
| 109 | 4.12.6 | Bug fixes |  | 5d | 2009-10-23 A | 2009-10-29 A | 108SS | 100% |  |  | Scott; Kevin | 80h | 80h |  |
| 110 | 4.12.7 | Request & schedule AppScan |  | 2h | 2009-10-23 A | 2009-10-23 A | 107 | 100% |  |  | Craig | 2h | 2h |  |
| 111 | 4.12.8 | Execution of AppScan complete | milestone | 0d | 2009-10-29 A | 2009-10-29 A | 110FS+4d | 100% | start no earlier than 2009-04-06 |  | Systems |  |  |  |
| 112 | 4.12.9 | Update deployment request for redeploy |  | 1h | 2009-10-28 A | 2009-10-28 A |  | 100% | start no earlier than 2009-10-28 |  | Kevin | 1h | 1h |  |
| 113 | 4.12.10 | Re-deploy to QA with fixes |  | 0.5d | 2009-10-28 A | 2009-10-28 A | 112 | 100% |  |  | Steve | 4h | 4h |  |
| 114 | 4.12.11 | Re-execute test cases |  | 12d | 2009-10-28 A | 2009-11-13 A | 113 | 100% |  |  | Steve | 96h | 96h |  |

| ID | WBS | Task | Type | Duration | Start | Finish | Predecessors | Complete | Constraint | Resources | Work | Actual work | Text12 |
| --- | --- | --- | --- | --- | --- | --- | --- | --- | --- | --- | --- | --- | --- |
| 115 | 4.13 | **Stage** |  | 26.88d | 2009-10-28 A | 2009-12-07 A |  | 100% |  |  | 165h | 165h |  |
| 116 | 4.13.1 | Receive Jboss containers & URLS from Systems Team | milestone | 0d | 2009-10-28 A | 2009-10-28 A |  | 100% | start no earlier than 2009-10-28 |  |  |  |  |
| 117 | 4.13.2 | Create Stage tag in SVN |  | 1h | 2009-11-13 A | 2009-11-13 A | 103 | 100% |  | Scott | 1h | 1h |  |
| 118 | 4.13.3 | Obtain approval to move to Stage |  | 1h | 2009-11-13 A | 2009-11-13 A | 103 | 100% | start no earlier than 2009-11-12 | Steve | 1h | 1h |  |
| 119 | 4.13.4 | Draft/Submit Deployment Request for Stage (API/Grid/DB) |  | 1h | 2009-11-13 A | 2009-11-13 A | 118 | 100% |  | Steve | 1h | 1h |  |
| 120 | 4.13.5 | Promote to Stage |  | 6d | 2009-11-13 A | 2009-11-23 A | 119 | 100% |  | Systems Team | 48h | 48h | 21995 |
| 121 | 4.13.6 | Request & schedule external AppScan |  | 2h | 2009-11-23 A | 2009-11-24 A | 120 | 100% | start no earlier than 2009-11-06 | Scott | 2h | 2h |  |
| 122 | 4.13.7 | Execute test cases |  | 6d | 2009-11-23 A | 2009-12-03 A | 120 | 100% |  | Steve | 48h | 48h |  |
| 123 | 4.13.8 | UAT Testing |  | 8d | 2009-11-23 A | 2009-12-07 A | 120 | 100% | start no earlier than 2009-11-19 | Denis | 64h | 64h |  |
| 124 | 5 | **Transition** |  | 44.12d | 2009-10-16 A | 2009-12-21 A |  | 100% |  |  | 1930h | 1930h |  |
| 125 | 5.1 | **Documentation** |  | 41.88d | 2009-10-16 A | 2009-12-16 A | 103SS | 100% |  |  | 1902h | 1902h |  |
| 126 | 5.1.1 | **Release Notes** |  | 10.12d | 2009-11-13 A | 2009-12-01 A |  | 100% |  |  | 24h | 24h |  |
| 127 | 5.1.1.1 | Draft Release notes - Wiki |  | 2d | 2009-11-13 A | 2009-11-18 A | 120SS | 100% | start no earlier than 2009-04-21 | Kevin | 16h | 16h |  |
| 128 | 5.1.1.2 | Finalize release notes (with Steve & Tracy) |  | 1d | 2009-12-01 A | 2009-12-01 A | 127 | 100% | start no earlier than 2009-12-01 | Craig | 8h | 8h |  |
| 129 | 5.1.1.3 | Completed release notes | milestone | 0d | 2009-12-01 A | 2009-12-01 A | 128 | 100% |  | Craig |  |  |  |
| 130 | 5.1.2 | **Update VKC Wiki Guides** |  | 25d | 2009-10-26 A | 2009-12-01 A |  | 100% |  |  | 1600h | 1600h |  |
| 131 | 5.1.2.1 | Design and Architecture Guide |  | 5w | 2009-10-26 A | 2009-12-01 A |  | 100% | start no earlier than 2009-10-26 | Craig; Marylyn | 400h | 400h |  |
| 132 | 5.1.2.2 | Programmer's Guide |  | 5w | 2009-10-26 A | 2009-12-01 A |  | 100% | start no earlier than 2009-10-26 | Craig; Marylyn | 400h | 400h |  |
| 133 | 5.1.2.3 | Administrator Guide |  | 5w | 2009-10-26 A | 2009-12-01 A |  | 100% | start no earlier than 2009-10-26 | Craig; Marylyn | 400h | 400h |  |
| 134 | 5.1.2.4 | Install Guide |  | 5w | 2009-10-26 A | 2009-12-01 A |  | 100% | start no earlier than 2009-10-26 | Craig; Marylyn | 400h | 400h |  |
| 135 | 5.1.3 | **Production announcements** |  | 4d | 2009-12-03 A | 2009-12-09 A | 122 | 100% |  |  | 32h | 32h |  |
| 136 | 5.1.3.1 | Draft release announcement |  | 3d | 2009-12-03 A | 2009-12-08 A |  | 100% |  | Traci | 24h | 24h |  |
| 137 | 5.1.3.2 | Send to Frank for approval |  | 1d | 2009-12-08 A | 2009-12-09 A | 136 | 100% |  | Jason | 8h | 8h |  |
| 138 | 5.1.4 | **NCICB webpage updates** |  | 7d | 2009-12-07 A | 2009-12-16 A | 115 | 100% |  |  | 152h | 152h |  |
| 139 | 5.1.4.1 | Complete updates |  | 1w | 2009-12-07 A | 2009-12-14 A |  | 100% |  | Tracy | 40h | 40h |  |

| ID | WBS | Task | Type | Duration | Start | Finish | Predecessors | Complete | Constraint | Resources | Work | Actual work | Text12 |
| --- | --- | --- | --- | --- | --- | --- | --- | --- | --- | --- | --- | --- | --- |
| 140 | 5.1.4.2 | **Send through the tiers for deployment** |  | 7d | 2009-12-07 A | 2009-12-16 A |  | 100% |  | Tracy | 112h | 112h |  |
| 141 | 5.1.4.2.1 | Dev |  | 1d | 2009-12-07 A | 2009-12-08 A |  | 100% |  | Tracy | 8h | 8h |  |
| 142 | 5.1.4.2.2 | Stage |  | 3d | 2009-12-08 A | 2009-12-11 A | 141 | 100% |  | Tracy | 24h | 24h |  |
| 143 | 5.1.4.2.3 | Prod |  | 3d | 2009-12-11 A | 2009-12-16 A | 142 | 100% |  | Tracy | 24h | 24h |  |
| 144 | 5.1.5 | **Deploy Website Updates** |  | 39.12d | 2009-10-16 A | 2009-12-14 A |  | 100% |  |  | 94h | 94h |  |
| 145 | 5.1.5.1 | **Dev** |  | 4.25d | 2009-10-16 A | 2009-10-22 A | 95 | 100% |  |  | 34h | 34h |  |
| 146 | 5.1.5.1.1 | Submit ticket through JIRA for Dev |  | 2h | 2009-10-16 A | 2009-10-16 A |  | 100% | start no earlier than 2009-04-13 | Craig | 2h | 2h |  |
| 147 | 5.1.5.1.2 | Deploy to Dev |  | 4d | 2009-10-16 A | 2009-10-22 A | 146 | 100% |  | Systems Team | 32h | 32h |  |
| 148 | 5.1.5.2 | **Stage** |  | 4.25d | 2009-11-13 A | 2009-11-19 A | 118 | 100% |  |  | 34h | 34h |  |
| 149 | 5.1.5.2.1 | Submit ticket through JIRA for Stage |  | 2h | 2009-11-13 A | 2009-11-13 A |  | 100% | start no earlier than 2009-04-22 | Craig | 2h | 2h |  |
| 150 | 5.1.5.2.2 | Deploy to Stage |  | 4d | 2009-11-16 A | 2009-11-19 A | 149 | 100% |  | Systems Team | 32h | 32h |  |
| 151 | 5.1.5.3 | **Prod** |  | 3.25d | 2009-12-08 A | 2009-12-14 A | 156 | 100% |  |  | 26h | 26h |  |
| 152 | 5.1.5.3.1 | Submit ticket through JIRA for Prod |  | 2h | 2009-12-08 A | 2009-12-09 A |  | 100% |  | Steve | 2h | 2h |  |
| 153 | 5.1.5.3.2 | Deploy to Prod |  | 3d | 2009-12-09 A | 2009-12-14 A | 152 | 100% |  | Systems Team | 24h | 24h |  |
| 154 | 5.2 | **Promote to Production** |  | 33.12d | 2009-11-02 A | 2009-12-21 A |  | 100% |  |  | 28h | 28h |  |
| 155 | 5.2.1 | Receive Jboss containers & URLS |  | 10d | 2009-11-02 A | 2009-11-13 A |  | 100% | start no earlier than 2009-11-02 |  |  |  |  |
| 156 | 5.2.2 | Obtain approval to move to Production |  | 1d | 2009-12-07 A | 2009-12-08 A | 115 | 100% | start no earlier than 2009-11-13 | Steve | 8h | 8h |  |
| 157 | 5.2.3 | Production tag in SVN (Use QA tag) |  | 1h | 2009-12-08 A | 2009-12-08 A | 156 | 100% |  | Craig | 1h | 1h |  |
| 158 | 5.2.4 | Draft/Submit Deployment Request (API/Grid/DB) |  | 2h | 2009-12-14 A | 2009-12-14 A | 156 | 100% | start no earlier than 2009-12-14 | Steve | 2h | 2h |  |
| 159 | 5.2.5 | Update Gforge | milestone | 0d | 2009-12-14 A | 2009-12-14 A | 158 | 100% | start no earlier than 2009-05-06 | Craig |  |  |  |
| 160 | 5.2.6 | Deploy to Production |  | 1d | 2009-12-17 A | 2009-12-17 A |  | 100% | start no earlier than 2009-12-17 | Systems | 8h | 8h | 21996 |
| 161 | 5.2.7 | Production testing |  | 1d | 2009-12-18 A | 2009-12-18 A | 160 | 100% | start no earlier than 2009-12-01 | Steve | 8h | 8h |  |
| 162 | 5.2.8 | Milestone - Production Deployment Complete | milestone | 0d | 2009-12-18 A | 2009-12-18 A | 161 | 100% |  |  |  |  |  |
| 163 | 5.2.9 | Send announcements for 5.1 |  | 1h | 2009-12-21 A | 2009-12-21 A | 162 | 100% |  | Frank | 1h | 1h |  |
